# 2-2

Schedule from MS Project, 2023-09-14 to 2024-01-05, 2 hours a day, costs in €, A marks actual dates.
Universite Clermont Auvergne

## Calendars

- SAE: Mon-Fri 08:00-10:00; Sat-Sun off.

## Resources

| Resource | Rate |
| --- | --- |
| Antoine PEREDERII | 20 |
| Kevin MONTEIRO | 20 |
| Paul LEVRAULT | 20 |
| David D'ALMEIDA | 20 |
| Antoine PINAGOT | 20 |

## Schedule

| ID | WBS | Task | Duration | Start | Finish | Predecessors | Complete | Remaining | Actual start | Total slack | Free slack | Resources | Work | Actual work | Cost | Actual cost |
| --- | --- | --- | --- | --- | --- | --- | --- | --- | --- | --- | --- | --- | --- | --- | --- | --- |
| 1 | 1 | **Étude de courbes de fréquence cardiaque** | 80.64d? | 2023-09-14 A | 2024-01-05 |  | 48% | 41.62d? |  | 0d |  |  | 738.1h | 307.44h | 14,762 | 6,148.8 |
| 2 | 1.1 | **1 - Management de projet** | 54.78d | 2023-09-14 A | 2023-11-30 |  | 86% | 7.76d |  | 25.85d |  |  | 188.5h | 140.1h | 3,770 | 2,802 |
| 3 | 1.1.1 | **1.1 - Recueil de besoins** | 38.5d | 2023-09-14 A | 2023-11-07 |  | 93% | 2.67d |  | 42.13d |  |  | 87h | 80.5h | 1,740 | 1,610 |
| 4 | 1.1.1.1 | 1.1.1 - Présentation general du projet | 2h | 2023-09-18 A | 2023-09-18 A | 13 | 100% |  |  |  |  | Antoine PEREDERII | 2h | 2h | 40 | 40 |
| 5 | 1.1.1.2 | 1.1.2 - Compte rendu 1 | 3h | 2023-09-22 A | 2023-09-22 A | 4, 12 | 100% |  |  |  |  | Antoine PEREDERII; Antoine PINAGOT; David D'ALMEIDA; Kevin MONTEIRO; Paul LEVRAULT | 7h | 7h | 140 | 140 |
| 6 | 1.1.1.3 | 1.1.3 - Compte rendu 2 | 5h | 2023-10-05 A | 2023-10-06 A | 7 | 100% |  |  |  |  | Antoine PEREDERII; Antoine PINAGOT; David D'ALMEIDA; Kevin MONTEIRO; Paul LEVRAULT | 25h | 25h | 500 | 500 |
| 7 | 1.1.1.4 | 1.1.4 - Backlog (users stories) | 5h | 2023-10-02 A | 2023-10-04 A | 5 | 100% |  |  |  |  | David D'ALMEIDA; Paul LEVRAULT | 10h | 10h | 200 | 200 |
| 8 | 1.1.1.5 | 1.1.5 - Compte Rendu (V2) | 7h | 2023-10-03 A | 2023-10-06 A | 5 | 100% |  |  |  |  | Antoine PEREDERII | 7h | 7h | 140 | 140 |
| 9 | 1.1.1.6 | 1.1.6 - Compte rendu 2 (V2) | 5h | 2023-10-06 A | 2023-10-10 A | 6 | 100% |  |  |  |  | Antoine PEREDERII | 5h | 5h | 100 | 100 |
| 10 | 1.1.1.7 | 1.1.7 - Rapport BDD | 2h | 2023-11-07 A | 2023-11-07 A | 37 | 100% |  |  |  |  | Antoine PEREDERII; Paul LEVRAULT; David D'ALMEIDA; Kevin MONTEIRO; Antoine PINAGOT | 10h | 10h | 200 | 200 |
| 11 | 1.1.1.8 | **1.1.5 - Rendez vous** | 4d | 2023-09-14 A | 2023-09-20 |  | 64% | 1.43d |  | 76.64d |  |  | 21h | 14.5h | 420 | 290 |
| 12 | 1.1.1.8.1 | 1.1.5.1 - Avec le tuteur | 4h | 2023-09-18 A | 2023-09-20 |  | 88% | 0.5h |  | 76.64d |  | Antoine PEREDERII; Antoine PINAGOT; David D'ALMEIDA; Kevin MONTEIRO; Paul LEVRAULT | 16h | 13.5h | 320 | 270 |
| 13 | 1.1.1.8.2 | 1.1.5.2 - Avec le client | 3h | 2023-09-14 | 2023-09-15 |  | 33% | 2h | 2023-09-15 | 24d | 20d | Antoine PEREDERII; Antoine PINAGOT; David D'ALMEIDA; Kevin MONTEIRO; Paul LEVRAULT | 5h | 1h | 100 | 20 |
| 14 | 1.1.2 | **1.2 - Organisation du travail en équipe** | 10d | 2023-09-15 A | 2023-09-28 A |  | 100% |  |  |  |  |  | 8h | 8h | 160 | 160 |
| 15 | 1.1.2.1 | 1.2.1 - Mise en place du kanban | 2h | 2023-09-15 A | 2023-09-28 A |  | 100% |  |  |  |  | Antoine PEREDERII; David D'ALMEIDA | 2h | 2h | 40 | 40 |
| 16 | 1.1.2.2 | 1.2.2 - Mise en place du codefirst | 3h | 2023-09-25 A | 2023-09-26 A |  | 100% |  |  |  |  | David D'ALMEIDA | 3h | 3h | 60 | 60 |
| 17 | 1.1.2.3 | 1.2.3 - Mise en place du notion | 2h | 2023-09-15 A | 2023-09-15 A |  | 100% |  |  |  |  | David D'ALMEIDA; Antoine PEREDERII | 2h | 2h | 40 | 40 |
| 18 | 1.1.2.4 | 1.2.4 - Mise en place du discord | 0.5h | 2023-09-15 A | 2023-09-15 A |  | 100% |  |  |  |  | Antoine PEREDERII; Antoine PINAGOT | 1h | 1h | 20 | 20 |
| 19 | 1.1.3 | **1.3 - Planification du projet** | 16.5d | 2023-09-20 A | 2023-10-12 A |  | 100% |  |  |  |  |  | 35h | 35h | 700 | 700 |
| 20 | 1.1.3.1 | 1.3.1 - WBS | 6h | 2023-09-20 A | 2023-09-22 A | 5 | 100% |  |  |  |  | Antoine PEREDERII; Kevin MONTEIRO | 10h | 10h | 200 | 200 |
| 21 | 1.1.3.2 | 1.3.2 - GANTT prévisionnel | 17h | 2023-09-29 A | 2023-10-12 A | 20 | 100% |  |  |  |  | Antoine PEREDERII; Paul LEVRAULT | 17h | 17h | 340 | 340 |
| 22 | 1.1.3.3 | 1.3.3 - PERT | 4h | 2023-10-09 A | 2023-10-11 A | 21 | 100% |  |  |  |  | Antoine PEREDERII; Antoine PINAGOT; Paul LEVRAULT | 8h | 8h | 160 | 160 |
| 23 | 1.1.4 | **1.4 - Suivi de projet** | 51.28d | 2023-09-20 A | 2023-11-30 |  | 46% | 27.76d |  | 25.85d |  |  | 58.5h | 16.6h | 1,170 | 332 |
| 24 | 1.1.4.1 | 1.4.1 - Indicateurs de suivi de projet | 3h | 2023-11-22 A | 2023-11-23 | 22 | 70% | 0.9h |  | 30.14d |  | David D'ALMEIDA; Antoine PEREDERII | 3h | 2.1h | 60 | 42 |
| 25 | 1.1.4.2 | 1.4.2 - Préparation des vidéos | 3h | 2023-11-28 | 2023-11-30 | 26 |  |  |  | 25.85d |  | Antoine PEREDERII; Antoine PINAGOT; David D'ALMEIDA; Kevin MONTEIRO; Paul LEVRAULT | 15h |  | 300 |  |
| 26 | 1.1.4.3 | 1.4.3 - Préparation des rapports globaux | 2h | 2023-11-27 | 2023-11-28 | 67 |  |  |  | 25.85d | 0d | Antoine PEREDERII; Antoine PINAGOT; David D'ALMEIDA; Kevin MONTEIRO; Paul LEVRAULT | 10h |  | 200 |  |
| 27 | 1.1.4.4 | 1.4.4 - Préparation oral 1 | 5h | 2023-11-14 A | 2023-11-24 A | 24 | 100% |  |  |  |  | Antoine PEREDERII; Antoine PINAGOT; David D'ALMEIDA; Kevin MONTEIRO; Paul LEVRAULT | 13h | 13h | 260 | 260 |
| 28 | 1.1.4.5 | 1.4.5 - Préparation oral 2 | 3.75h | 2023-11-27 | 2023-11-28 | 27 |  |  |  | 27.26d |  | Antoine PEREDERII; Antoine PINAGOT; Kevin MONTEIRO; Paul LEVRAULT | 15h |  | 300 |  |
| 29 | 1.1.4.6 | 1.4.6 - GANTT réel | 1.5h | 2023-11-14 A | 2023-11-28 | 67 | 67% | 0.5h |  | 28.1d |  | Antoine PINAGOT; Antoine PEREDERII | 2h | 1h | 40 | 20 |
| 30 | 1.1.4.7 | 1.4.7 - Graphe de compétence | 0.5h | 2023-09-20 A | 2023-09-20 A |  | 100% |  |  |  |  | Kevin MONTEIRO | 0.5h | 0.5h | 10 | 10 |

| ID | WBS | Task | Type | Duration | Start | Finish | Predecessors | Complete | Remaining | Total slack | Free slack | Resources | Work | Actual work | Cost | Actual cost |
| --- | --- | --- | --- | --- | --- | --- | --- | --- | --- | --- | --- | --- | --- | --- | --- | --- |
| 31 | 1.2 | **2 - Développement** |  | 73.64d? | 2023-09-25 A | 2024-01-05 |  | 38% | 45.54d? | 0d |  |  | 549.6h | 167.34h | 10,992 | 3,346.8 |
| 32 | 1.2.1 | **2.1 - Conception** |  | 36.05d | 2023-09-25 A | 2023-11-14 |  | 48% | 18.62d | 37.58d |  |  | 133h | 74.64h | 2,660 | 1,492.8 |
| 33 | 1.2.1.1 | 2.1.1 - Communication (reseaux) |  | 17.2h | 2023-10-06 A | 2023-11-14 | 34 | 7% | 16h | 0.75d | 0d | Antoine PEREDERII; Paul LEVRAULT | 20h | 1.2h | 400 | 24 |
| 34 | 1.2.1.2 | 2.1.2 - Architecture |  | 12h | 2023-09-29 A | 2023-11-02 | 35 | 7% | 11.16h | 0d |  | Antoine PEREDERII; David D'ALMEIDA | 14h | 0.84h | 280 | 16.8 |
| 35 | 1.2.1.3 | 2.1.3 - Diagramme de classes |  | 11.14h | 2023-09-25 A | 2023-10-25 | 37 | 43% | 6.34h | 0d |  | Antoine PEREDERII; Antoine PINAGOT; David D'ALMEIDA | 26h | 11.2h | 520 | 224 |
| 36 | 1.2.1.4 | 2.1.4 - Maquettes |  | 12h | 2023-09-28 A | 2023-10-04 A | 5 | 100% |  |  |  | Antoine PINAGOT | 12h | 12h | 240 | 240 |
| 37 | 1.2.1.5 | 2.1.5 - MCD & MLD |  | 8h | 2023-10-16 A | 2023-10-19 A | 36 | 100% |  |  |  | David D'ALMEIDA; Paul LEVRAULT; Kevin MONTEIRO; Antoine PINAGOT; Antoine PEREDERII | 32h | 32h | 640 | 640 |
| 38 | 1.2.1.6 | 2.1.6 - Diagramme de cas d'utilisation |  | 10h | 2023-10-16 A | 2023-10-20 | 13 | 80% | 2h | 8.55d | 5d | Kevin MONTEIRO; Antoine PEREDERII | 12h | 10h | 240 | 200 |
| 39 | 1.2.1.7 | 2.1.7 - Charte graphique |  | 16h | 2023-10-10 A | 2023-10-20 | 9 | 40% | 9.6h | 54.63d |  | Antoine PINAGOT | 16h | 6.4h | 320 | 128 |
| 40 | 1.2.1.8 | 2.1.8 - Logo |  | 1h | 2023-10-20 A | 2023-10-20 A |  | 100% |  |  |  | David D'ALMEIDA | 1h | 1h | 20 | 20 |
| 41 | 1.2.2 | **2.2 - Client Web et Mobile** |  | 26.07d? | 2023-10-27 A | 2023-12-04 |  | 20% | 20.85d? | 23.58d |  |  | 146.1h | 13.75h | 2,922 | 275 |
| 42 | 1.2.2.1 | 2.2.1 - Interface utilisateur client (Vues) |  | 15h? | 2023-11-06 A | 2023-11-15 | 34 | 35% | 9.75h? | 36.13d |  | Antoine PINAGOT | 15h | 5.25h | 300 | 105 |
| 43 | 1.2.2.2 | 2.2.2 - Gestion des données client |  | 41h? | 2023-11-02 | 2023-12-01 | 34 |  |  | 23.58d | 0d | Antoine PEREDERII; David D'ALMEIDA; Paul LEVRAULT | 117h |  | 2,340 |  |
| 44 | 1.2.2.3 | 2.2.3 - Authentification Web et Mobile client |  | 1.5h | 2023-12-01 | 2023-12-04 | 33, 43, 47, 48, 49, 69, 70, 71, 72, 73, 74, 75 |  |  | 23.58d |  | Antoine PINAGOT; Kevin MONTEIRO; David D'ALMEIDA | 3h |  | 60 |  |
| 45 | 1.2.2.4 | 2.2.4 - Récupération des données de fréquence cardiaque |  | 5h | 2023-10-27 A | 2023-11-03 | 34 | 80% | 1h | 45.08d |  | Antoine PEREDERII | 5h | 4h | 100 | 80 |
| 46 | 1.2.2.5 | 2.2.5 - Définitions des algoritmes d'analyse de la fréquence cardiaque | milestone | 0h | 2023-11-14 | 2023-11-21 | 33 |  |  | 32.58d |  | David D'ALMEIDA |  |  |  |  |
| 47 | 1.2.2.6 | 2.2.6 - Mise en place Bootstrap |  | 3.6h | 2023-10-28 A | 2023-11-03 | 34, 38 | 56% | 1.6h | 43.28d | 19.7d | Antoine PINAGOT | 3.6h | 2h | 72 | 40 |
| 48 | 1.2.2.7 | 2.2.7 - Mise en place talwind |  | 1.5h | 2023-10-28 A | 2023-10-30 A | 34, 38 | 100% |  |  |  | Antoine PINAGOT | 1.5h | 1.5h | 30 | 30 |
| 49 | 1.2.2.8 | 2.2.8 - Mise en place lead PHPStorm |  | 1h | 2023-10-28 A | 2023-10-30 A | 34, 38 | 100% |  |  |  | David D'ALMEIDA | 1h | 1h | 20 | 20 |
| 50 | 1.2.3 | **2.3 - Web admin et monitorin** |  | 11.75d | 2023-11-02 | 2023-11-20 |  |  |  | 33.83d |  |  | 25h |  | 500 |  |
| 51 | 1.2.3.1 | 2.3.1 - Authentification admin et monitoring |  | 7.5h | 2023-11-14 | 2023-11-20 | 33 |  |  | 33.83d |  | Antoine PEREDERII; Antoine PINAGOT | 15h |  | 300 |  |
| 52 | 1.2.3.2 | 2.3.2 - Interface utilisateur admin (Vues) |  | 10h | 2023-11-02 | 2023-11-09 | 34 |  |  | 40.58d |  | Antoine PINAGOT | 10h |  | 200 |  |
| 53 | 1.2.4 | **2.4 - Base de données** |  | 38.5d | 2023-10-20 A | 2023-12-13 |  | 15% | 32.67d | 16.64d |  |  | 25h | 2.45h | 500 | 49 |
| 54 | 1.2.4.1 | 2.4.1 - Création des tables |  | 2h | 2023-10-20 A | 2023-10-20 A | 43 | 100% |  |  |  | Paul LEVRAULT | 2h | 2h | 40 | 40 |
| 55 | 1.2.4.2 | 2.4.2 - Ajout des données |  | 2.17h | 2023-10-20 A | 2023-10-23 | 54 | 21% | 1.73h | 52.27d | 35.64d | Antoine PINAGOT; Antoine PEREDERII | 3h | 0.45h | 60 | 9 |
| 56 | 1.2.4.3 | 2.4.3 - Mise en place d'un système de backup |  | 6h | 2023-10-23 | 2023-12-12 | 54 |  |  | 16.64d | 0d | Antoine PEREDERII; David D'ALMEIDA | 12h |  | 240 |  |
| 57 | 1.2.4.4 | 2.4.4 - Création des fonctions |  | 4h | 2023-10-23 | 2023-10-24 | 54 |  |  | 52.13d |  | Antoine PINAGOT | 4h |  | 80 |  |
| 58 | 1.2.4.5 | 2.4.5 - Création des index |  | 2h | 2023-12-12 | 2023-12-13 | 55, 56 |  |  | 16.64d |  | Antoine PEREDERII; David D'ALMEIDA | 4h |  | 80 |  |

| ID | WBS | Task | Duration | Start | Finish | Predecessors | Complete | Remaining | Total slack | Resources | Work | Actual work | Cost | Actual cost |
| --- | --- | --- | --- | --- | --- | --- | --- | --- | --- | --- | --- | --- | --- | --- |
| 59 | 1.2.5 | **2.5 - Serveur et comùmunication de services** | 45.58d | 2023-11-02 | 2024-01-05 |  |  |  | 0d |  | 48h |  | 960 |  |
| 60 | 1.2.5.1 | 2.5.1 - Authentification serveur | 4h | 2023-11-14 | 2023-12-29 | 33 |  |  | 0.75d | Antoine PINAGOT; Kevin MONTEIRO | 4h |  | 80 |  |
| 61 | 1.2.5.2 | 2.5.2 - Stockage cloud | 3.33h | 2023-12-29 | 2024-01-02 | 60, 62 |  |  | 0d | David D'ALMEIDA; Antoine PEREDERII; Antoine PINAGOT | 10h |  | 200 |  |
| 62 | 1.2.5.3 | 2.5.3 - Routage | 18h | 2023-11-02 | 2023-12-29 | 34 |  |  | 0d | Antoine PEREDERII; Antoine PINAGOT; David D'ALMEIDA | 18h |  | 360 |  |
| 63 | 1.2.5.4 | 2.5.4 - Gestion des données serveur | 5.33h | 2024-01-02 | 2024-01-05 | 61 |  |  | 0d | Antoine PINAGOT; Antoine PEREDERII; David D'ALMEIDA | 16h |  | 320 |  |
| 64 | 1.2.6 | **2.6 - Integration continue et livraison continue (CI/ CD)** | 28d | 2023-10-27 A | 2023-12-06 |  | 19% | 22.59d | 21.66d |  | 106h | 10h | 2,120 | 200 |
| 65 | 1.2.6.1 | 2.6.1 - Tests | 35h | 2023-10-27 A | 2023-11-22 | 34 | 20% | 28h | 0d | Antoine PEREDERII; Antoine PINAGOT; David D'ALMEIDA; Kevin MONTEIRO; Paul LEVRAULT | 78h | 7h | 1,560 | 140 |
| 66 | 1.2.6.2 | 2.6.2 - Conteneurisation et déploiement | 8h | 2023-10-27 A | 2023-12-06 | 34 | 30% | 5.6h | 21.66d | Antoine PEREDERII; David D'ALMEIDA | 8h | 2.4h | 160 | 48 |
| 67 | 1.2.6.3 | 2.6.3 - Documentations (swagger, schéma, …) | 6.67h | 2023-11-15 A | 2023-11-27 | 65 | 3% | 6.47h | 0d | Antoine PEREDERII; Antoine PINAGOT; David D'ALMEIDA | 20h | 0.6h | 400 | 12 |
| 68 | 1.2.7 | **2.7 Configuration** | 11d? | 2023-10-06 A | 2023-10-20 A |  | 100% |  |  |  | 66.5h | 66.5h | 1,330 | 1,330 |
| 69 | 1.2.7.1 | 2.6.1 - Installation Twig | 0.5h | 2023-10-06 A | 2023-10-06 A | 34 | 100% |  |  | Antoine PINAGOT | 0.5h | 0.5h | 10 | 10 |
| 70 | 1.2.7.2 | 2.6.2 - Bootstrap | 2h | 2023-10-06 A | 2023-10-06 A | 34 | 100% |  |  | Antoine PINAGOT | 2h | 2h | 40 | 40 |
| 71 | 1.2.7.3 | 2.6.3 - PHP Unite | 10h | 2023-10-11 A | 2023-10-16 A | 43 | 100% |  |  | David D'ALMEIDA; Paul LEVRAULT | 20h | 20h | 400 | 400 |
| 72 | 1.2.7.4 | 2.6.4 - Node | 10h | 2023-10-11 A | 2023-10-16 A | 43 | 100% |  |  | Antoine PINAGOT | 10h | 10h | 200 | 200 |
| 73 | 1.2.7.5 | 2.6.5 - Autoloader | 2h | 2023-10-06 A | 2023-10-06 A | 34 | 100% |  |  | Antoine PINAGOT | 2h | 2h | 40 | 40 |
| 74 | 1.2.7.6 | 2.6.6 - Composer | 2h | 2023-10-06 A | 2023-10-06 A | 34 | 100% |  |  | Antoine PINAGOT; David D'ALMEIDA | 2h | 2h | 40 | 40 |
| 75 | 1.2.7.7 | 2.6.7 - Architecture Repository | 30h? | 2023-10-06 A | 2023-10-20 A | 34 | 100% |  |  | Antoine PINAGOT; Kevin MONTEIRO | 30h | 30h | 600 | 600 |
